# iB-NDS integrations v1.5

Schedule from MS Project, 2012-01-02 to 2012-07-10, A marks actual dates.
NDS Corporation

## Calendars

- Standard: Mon-Fri 08:00-12:00, 13:00-17:00; Sat-Sun off. Exceptions (off unless hours are given): 2012-01-06, 2012-01-08 08:00-12:00, 13:00-17:00, 2012-01-13, 2012-01-15 08:00-12:00, 13:00-17:00.

## Resources

| Resource |
| --- |
| Station Engineer |
| iBiquity |
| iBiquity/Station Engineer |

## Schedule

| ID | WBS | Task | Duration | Start | Finish | Predecessors | Complete | Remaining | Total slack | Free slack | Constraint | Resources | Work | Actual work |
| --- | --- | --- | --- | --- | --- | --- | --- | --- | --- | --- | --- | --- | --- | --- |
| 1 | 1 | **Station Assessment** | 77d | 2012-01-02 A | 2012-04-17 |  | 40% | 46.2d | 60d |  |  |  | 200h | 80h |
| 2 | 1.1 | Coordinate with iBiquity on station check-list | 2w | 2012-01-02 A | 2012-01-15 A |  | 100% |  |  |  | start no earlier than 2006-10-16 | Station Engineer | 80h | 80h |
| 3 | 1.2 | Determine hardware and software configurations/versions | 1w | 2012-01-16 | 2012-01-20 | 2 |  |  | 27d | 0.75d | finish no earlier than 2012-01-20 | iBiquity/Station Engineer | 40h |  |
| 4 | 1.3 | Determine network configurations | 10d | 2012-01-16 | 2012-04-17 | 3SS |  |  | 60d |  | finish no earlier than 2012-04-17 | Station Engineer | 80h |  |
| 6 | 2 | **Cost assessment and proposal** | 15d | 2012-02-03 | 2012-02-23 |  |  |  | 18d |  |  |  | 200h |  |
| 7 | 2.1 | **Prepare capital costs proposal** | 10d | 2012-02-03 | 2012-02-16 | 3 |  |  | 18d | 0d |  |  | 80h |  |
| 8 | 2.1.1 | - hardware / software | 10d | 2012-02-03 | 2012-02-16 |  |  |  | 18d | 5d | start no earlier than 2012-02-03 | Station Engineer | 80h |  |
| 9 | 2.2 | **Prepare proposal for deployment** | 5d | 2012-02-17 | 2012-02-23 | 7 |  |  | 18d | 0d |  |  | 120h |  |
| 10 | 2.2.1 | costing | 1w | 2012-02-17 | 2012-02-23 |  |  |  | 18d |  |  | Station Engineer | 40h |  |
| 11 | 2.2.2 | duration | 1w | 2012-02-17 | 2012-02-23 |  |  |  | 18d |  |  | Station Engineer | 40h |  |
| 12 | 2.2.3 | resources | 1w | 2012-02-17 | 2012-02-23 |  |  |  | 18d |  |  | Station Engineer | 40h |  |
| 14 | 3 | **Initial deployment planning** | 39d | 2012-02-24 | 2012-04-18 | 9 |  |  | 18d |  |  |  | 400h |  |
| 15 | 3.1 | Schedule planned roll-out | 10d | 2012-03-08 | 2012-03-21 |  |  |  | 29d |  | start no earlier than 2012-03-08 | Station Engineer | 80h |  |
| 16 | 3.2 | **Initial deployment plan** | 10d | 2012-02-24 | 2012-03-08 | 8, 3, 7 |  |  | 88d |  |  |  | 80h |  |
| 17 | 3.2.1 | prioritize station roll-out | 2w | 2012-02-24 | 2012-03-08 | 3 |  |  | 88d |  |  | iBiquity/Station Engineer | 80h |  |
| 18 | 3.3 | Equipment RFQs - hardware / software upgrades | 4w | 2012-03-22 | 2012-04-18 | 9SS, 8, 7, 10 |  |  | 59d |  | start no earlier than 2012-03-22 | Station Engineer | 160h |  |
| 19 | 3.4 | Testing/deployment plan as equipment received | 10d | 2012-02-24 | 2012-03-08 |  |  |  | 18d | 9d |  | iBiquity/Station Engineer | 80h |  |
| 21 | 4 | **Station Deployment** | 59d | 2012-03-22 | 2012-06-12 |  |  |  | 0d |  |  |  | 400h |  |
| 22 | 4.1 | Schedule installation with vendor support | 2w | 2012-03-22 | 2012-04-04 | 19 |  |  | 9d | 0d | start no earlier than 2012-03-22 | Station Engineer | 80h |  |
| 23 | 4.2 | Prepare training plan/instructions for station install | 10d | 2012-04-05 | 2012-04-18 | 22 |  |  | 9d |  |  | iBiquity/Station Engineer | 80h |  |
| 24 | 4.3 | Initial field trial/install | 2w | 2012-05-02 | 2012-05-15 | 23, 15 |  |  | 0d |  | start no earlier than 2012-05-02 | iBiquity/Station Engineer | 80h |  |
| 25 | 4.4 | Full network roll-out | 4w | 2012-05-16 | 2012-06-12 | 24 |  |  | 0d |  |  | Station Engineer | 160h |  |
| 27 | 5 | **Monitoring/Feedback** | 20d? | 2012-06-13 | 2012-07-10 |  |  |  | 0d |  |  |  | 440h |  |
| 28 | 5.1 | Broadcast monitor installs | 4w | 2012-06-13 | 2012-07-10 | 25 |  |  | 0d |  |  | Station Engineer | 160h |  |
| 29 | 5.2 | Establish monitoring and feedback procedures | 2w? | 2012-06-26 | 2012-07-09 | 25 |  |  | 1d | 0d | start no earlier than 2012-06-26 | iBiquity/Station Engineer | 80h |  |
| 30 | 5.3 | Prepare material for ongoing debugging and fault maintenance | 2w? | 2012-06-26 | 2012-07-09 | 29SS |  |  | 1d |  |  | iBiquity/Station Engineer | 80h |  |
| 31 | 5.4 | HD Radio Task Force audit/report card | 3w | 2012-06-13 | 2012-07-03 | 25 |  |  | 5d |  |  | Station Engineer | 120h |  |
